# Gantt project

Schedule from MS Project, 2012-07-02 to 2012-10-23, costs in €.
Hewlett-Packard

## Calendars

- Estándar: Mon-Fri 09:00-13:00, 15:00-19:00; Sat-Sun off.

## Resources

| Resource | Rate |
| --- | --- |
| Mason | 21 |
| Labourer | 19 |
| Hammersmith | 21 |
| Carpenter | 15 |

## Schedule

| ID | WBS | Task | Duration | Start | Finish | Predecessors | Total slack | Free slack | Constraint | Resources | Work | Cost |
| --- | --- | --- | --- | --- | --- | --- | --- | --- | --- | --- | --- | --- |
| 1 | 1 | **TORDENSJOLKSGADE** | 82d | 2012-07-02 | 2012-10-23 |  | 0d |  |  |  | 2576h | 5,432,621.86 |
| 2 | 1.1 | Elevator vertical pathway | 3d | 2012-07-18 | 2012-07-20 | 16 | 1d |  |  | Mason [200%]; Labourer | 72h | 309,397.04 |
| 3 | 1.2 | Installations | 7.5d | 2012-09-03 | 2012-09-12 | 8 | 15.5d |  |  | Mason [200%]; Labourer | 120h | 1,118,278.64 |
| 4 | 1.3 | Establishe site | 3d | 2012-07-02 | 2012-07-04 |  | 1d | 0d | start no earlier than 2012-07-02 | Mason; Labourer [300%] | 96h | 250,677 |
| 5 | 1.4 | Demolition | 7d | 2012-07-05 | 2012-07-13 | 4 | 1d | 0d | start no earlier than 2012-07-04 | Mason; Labourer [300%] | 224h | 221,729.28 |
| 6 | 1.5 | Foundation floor | 4d | 2012-07-24 | 2012-07-27 | 17 | 4d |  | start no earlier than 2012-07-24 | Hammersmith [300%]; Mason [200%]; Labourer | 192h | 350,612 |
| 7 | 1.6 | Internal walls | 14d | 2012-08-03 | 2012-08-22 | 6, 13, 14 | 0d |  |  | Labourer [300%] | 336h | 172,671 |
| 8 | 1.7 | Steel structure | 7d | 2012-08-23 | 2012-08-31 | 7 | 0d |  |  | Mason [200%]; Hammersmith; Labourer | 224h | 466,799 |
| 9 | 1.8 | Fire staircase | 4d | 2012-09-03 | 2012-09-06 | 8 | 0d |  |  | Hammersmith; Mason [200%]; Labourer | 128h | 72,760 |
| 10 | 1.9 | External walls | 5d | 2012-09-07 | 2012-09-13 | 9 | 0d |  |  | Labourer [300%]; Mason [200%] | 200h | 84,574.08 |
| 11 | 1.10 | Carpentry & finishes | 14d | 2012-09-14 | 2012-10-03 | 10 | 0d |  |  | Carpenter [200%]; Labourer | 336h | 119,053 |
| 12 | 1.11 | Furniture | 14d | 2012-10-04 | 2012-10-23 | 11, 3 | 0d |  |  | Carpenter; Labourer | 168h | 301,761 |
| 13 | 1.12 | Floors | 3d | 2012-07-24 | 2012-07-26 | 16 | 5d |  | start no earlier than 2012-07-24 | Labourer; Mason | 48h | 9,232 |
| 14 | 1.13 | Main stairs + elevator | 8d | 2012-07-24 | 2012-08-02 | 2, 16 | 0d |  | start no earlier than 2012-07-24 | Hammersmith; Labourer; Mason [200%] | 256h | 1,092,665 |
| 15 | 1.14 | Excavation | 2d | 2012-07-16 | 2012-07-17 | 5 | 4d | 0d | start no earlier than 2012-07-16 | Labourer [200%]; Mason | 48h | 689,648.82 |
| 16 | 1.15 | Underpinning | 2d | 2012-07-16 | 2012-07-17 | 5 | 1d | 0d | start no earlier than 2012-07-16 | Mason; Labourer | 32h | 39,340 |
| 17 | 1.16 | Retaining wall | 4d | 2012-07-18 | 2012-07-23 | 15, 16 | 4d | 0d | start no earlier than 2012-07-18 | Hammersmith; Labourer; Mason | 96h | 133,424 |
